Schedule from MS Project, 2017-12-07 to 2018-03-30.

## Calendars

- Standard: Mon-Fri 08:00-12:00, 13:00-17:00; Sat-Sun off. Exceptions (off unless hours are given): 2017-12-25 to 2018-01-07 (Vancances hivers), 2018-01-13 08:00-12:00, 13:00-17:00.

## Resources

| Resource |
| --- |
| Aymeric BOUVARD |
| Jocelyn Tan |
| Alexandre SINTUREL |
| Romain ruffieux |
| Jean |

## Schedule

| ID | WBS | Task | Duration | Start | Finish | Predecessors | Total slack | Free slack | Constraint | Work |
| --- | --- | --- | --- | --- | --- | --- | --- | --- | --- | --- |
| 1 | 1 | **Preparation YETS** | 7d | 2017-12-07 | 2017-12-15 |  | 12d | 0d |  |  |
| 2 | 1.1 | Enlevement de l'escalier passerelle 193-393 | 2d | 2017-12-07 | 2017-12-08 |  | 8d | 0d | start no earlier than 2017-12-07 |  |
| 3 | 1.2 | Suppression bloc de ventilations | 5d | 2017-12-11 | 2017-12-15 | 2 | 8d | 0d | start no earlier than 2017-12-11 |  |
| 4 | 1.3 | Enlevement exposion aimants | 5d | 2017-12-11 | 2017-12-15 | 3SS | 8d | 0d | start no earlier than 2017-12-11 |  |
| 5 | 1.4 | Enlevement tapis de sol circuit de visite | 5d | 2017-12-11 | 2017-12-15 | 4SS | 8d | 0d | start no earlier than 2017-12-11 |  |
| 6 | 1.5 | Retrait des barrieres cote pont roulant zone de visite | 5d | 2017-12-11 | 2017-12-15 | 5SS | 8d |  | start no earlier than 2017-12-11 |  |
| 7 | 2 | **Consignation AD Ring** | 1d? | 2017-12-18 | 2017-12-18 | 1 | 12d | 0d |  |  |
| 8 | 2.1 | Consignation électrique | 1d? | 2017-12-18 | 2017-12-18 |  | 8d | 0d | start no earlier than 2017-12-18 |  |
| 9 | 3 | **EYETS 2016-2017** | 55d? | 2017-12-19 | 2018-03-16 | 7 | 0d |  |  | 24h |
| 10 | 3.1 | **EN-EA** | 40d | 2017-12-19 | 2018-02-23 |  | 15d |  |  |  |
| 11 | 3.1.1 | Nettoyage cable ligne 8000 | 40d | 2017-12-19 | 2018-02-23 |  | 15d |  |  |  |
| 12 | 3.2 | **MSC** | 55d? | 2017-12-19 | 2018-03-16 |  | 0d |  |  |  |
| 13 | 3.2.1 | **QDN55** | 54d? | 2017-12-20 | 2018-03-16 |  | 0d |  |  |  |
| 14 | 3.2.1.1 | Ouverture Blindage | 1d | 2018-01-08 | 2018-01-08 |  | 3d | 0d | start no earlier than 2018-01-08 |  |
| 15 | 3.2.1.2 | Déconnexion vide | 1d? | 2017-12-20 | 2017-12-20 | 90SS | 7d | 0d | start no earlier than 2017-01-06 |  |
| 16 | 3.2.1.3 | Déconnexion élec et Hyrdaulique | 1d? | 2017-12-20 | 2017-12-20 | 15SS | 53d |  |  |  |
| 17 | 3.2.1.4 | Enlèvement QDN55 | 1d | 2018-01-09 | 2018-01-09 | 15SS, 14 | 8d | 0d | start no earlier than 2017-12-01 |  |
| 18 | 3.2.1.5 | Transfert QDN55 au 867 | 1d? | 2018-01-09 | 2018-01-09 | 17SS | 3d | 0d |  |  |
| 19 | 3.2.1.6 | Remise en état QDN55 | 20d | 2018-01-10 | 2018-02-05 | 18 | 8d | 0d |  |  |
| 20 | 3.2.1.7 | Transfert QDN55 au 193 | 1d? | 2018-02-06 | 2018-02-06 | 19 | 8d | 0d |  |  |
| 21 | 3.2.1.8 | Remise en place QDN55 dans AD Ring | 1d? | 2018-02-06 | 2018-02-06 | 20SS, 93SS | 8d | 0d |  |  |
| 22 | 3.2.1.9 | Alignement | 1d? | 2018-02-07 | 2018-02-07 | 21 | 9d | 0d |  |  |
| 23 | 3.2.1.10 | Reconnexion vide | 1d? | 2018-02-08 | 2018-02-08 | 22 | 9d | 0d |  |  |
| 24 | 3.2.1.11 | Pump down Leak check | 3d | 2018-02-08 | 2018-02-12 | 23SS | 9d | 0d |  |  |
| 25 | 3.2.1.12 | Préparation Bakeout | 1d | 2018-02-26 | 2018-02-26 | 24, 99SS | 0d |  |  |  |
| 26 | 3.2.1.13 | Bake out | 14d | 2018-02-27 | 2018-03-16 | 25, 100SS | 0d |  | start no earlier than 2017-03-06 |  |
| 27 | 3.2.1.14 | Décablage Bakeout | 1d | 2018-03-16 | 2018-03-16 | 26FF | 0d |  |  |  |
| 28 | 3.2.1.15 | Fermeture Blindage | 1d? | 2018-02-13 | 2018-02-13 | 24 | 22d | 0d |  |  |
| 29 | 3.2.1.16 | Remise en place exposition visite | 1d? | 2018-02-14 | 2018-02-14 | 28 | 22d | 0d | start no earlier than 2017-03-30 |  |

| ID | WBS | Task | Duration | Start | Finish | Predecessors | Total slack | Free slack | Constraint |
| --- | --- | --- | --- | --- | --- | --- | --- | --- | --- |
| 30 | 3.2.2 | **QFN56** | 54d? | 2017-12-20 | 2018-03-16 |  | 0d |  |  |
| 31 | 3.2.2.1 | Ouverture blindage | 1d | 2018-01-08 | 2018-01-08 | 14SS | 49d | 0d | start no earlier than 2017-01-11 |
| 32 | 3.2.2.2 | Déconnexion vide | 1d | 2017-12-20 | 2017-12-20 | 15SS | 53d | 0d | finish no earlier than 2017-01-13 |
| 33 | 3.2.2.3 | Déconnexion électrique et hydraulique | 1d? | 2017-12-20 | 2017-12-20 | 32SS | 21d | 0d | start no earlier than 2017-01-16 |
| 34 | 3.2.2.4 | Déconnexion equipement BI | 1d? | 2017-12-20 | 2017-12-20 | 33SS | 53d | 3d | start no earlier than 2017-01-13 |
| 35 | 3.2.2.5 | Enlèvement QDFN56 | 1d? | 2018-01-09 | 2018-01-09 | 31, 33SS, 34SS | 49d |  | start no earlier than 2017-01-16 |
| 36 | 3.2.2.6 | Transfert QDFN56 au 867 | 1d? | 2018-01-09 | 2018-01-09 | 18SS | 4d | 0d |  |
| 37 | 3.2.2.7 | Remise en état QDFN56 | 20d | 2018-01-10 | 2018-02-05 | 36, 19SS | 8d | 0d |  |
| 38 | 3.2.2.8 | Transfert QDFN56 au 193 | 1d? | 2018-02-06 | 2018-02-06 | 37, 20SS | 8d | 1d |  |
| 39 | 3.2.2.9 | Remise en place QDFN56 dans AD Ring | 2d | 2018-02-06 | 2018-02-07 | 38SS, 21SS | 8d | 0d |  |
| 40 | 3.2.2.10 | Alignement | 1d? | 2018-02-08 | 2018-02-08 | 39 | 8d | 0d |  |
| 41 | 3.2.2.11 | Reconnexion vide | 1d? | 2018-02-09 | 2018-02-09 | 40 | 8d | 0d |  |
| 42 | 3.2.2.12 | Pump down leak check | 3d | 2018-02-09 | 2018-02-13 | 24SS, 41SS | 8d |  |  |
| 43 | 3.2.2.13 | Préparation bakeout | 1d | 2018-02-26 | 2018-02-26 | 25SS, 42 | 0d |  | start no earlier than 2017-01-05 |
| 44 | 3.2.2.14 | Bakeout | 14d | 2018-02-27 | 2018-03-16 | 26SS, 43 | 0d |  |  |
| 45 | 3.2.2.15 | Décablage Bakeout | 1d | 2018-03-16 | 2018-03-16 | 27SS, 44FF | 0d |  |  |
| 46 | 3.2.2.16 | Fermeture blindage | 1d? | 2018-02-13 | 2018-02-13 | 28SS | 22d | 0d |  |
| 47 | 3.2.2.17 | Remise en place exposition visite | 1d? | 2018-02-14 | 2018-02-14 | 46, 29SS | 22d | 0d | start no earlier than 2017-03-30 |
| 48 | 3.2.3 | **BHS52** | 55d? | 2017-12-19 | 2018-03-16 |  | 0d |  |  |
| 49 | 3.2.3.1 | Ouverture Blindage | 4d | 2017-12-19 | 2017-12-22 |  | 51d |  |  |
| 50 | 3.2.3.2 | Deconnexion vide | 1d? | 2017-12-20 | 2017-12-20 | 88SS | 21d | 0d |  |
| 51 | 3.2.3.3 | Deconnexion hydraulique et electrique | 1d? | 2017-12-20 | 2017-12-20 | 33SS | 21d | 0d |  |
| 52 | 3.2.3.4 | Enlevement BHS52 | 1d | 2017-12-21 | 2017-12-21 | 51, 50, 89 | 24d | 0d | start no earlier than 2017-12-19 |
| 53 | 3.2.3.5 | Transfert BHS52 au 867 | 1d? | 2017-12-21 | 2017-12-21 | 52SS | 21d | 0d |  |
| 54 | 3.2.3.6 | Remise en etat BHS52 | 25d | 2017-12-22 | 2018-02-07 | 53 | 24d | 0d |  |
| 55 | 3.2.3.7 | Transfert BHS52 au 193 | 1d? | 2018-02-08 | 2018-02-08 | 54 | 24d | 3d |  |
| 56 | 3.2.3.8 | Remise en place BHS52 dans AD Ring | 1d? | 2018-02-13 | 2018-02-13 | 96SS, 55SS | 21d | 0d |  |
| 57 | 3.2.3.9 | Alignement | 1d? | 2018-02-14 | 2018-02-14 | 56 | 21d | 0d |  |
| 58 | 3.2.3.10 | Reconnexion vide | 1d? | 2018-02-15 | 2018-02-15 | 57 | 21d |  |  |
| 59 | 3.2.3.11 | Pump down leak check | 1d? | 2018-02-16 | 2018-02-16 | 98SS | 20d |  |  |
| 60 | 3.2.3.12 | Preparation bakeout | 1d? | 2018-02-26 | 2018-02-26 | 43SS | 14d |  |  |
| 61 | 3.2.3.13 | Bakeout | 14d | 2018-02-27 | 2018-03-16 | 44SS | 0d |  |  |
| 62 | 3.2.3.14 | Decablage Bakeout | 1d? | 2018-03-16 | 2018-03-16 | 45SS | 0d |  |  |
| 63 | 3.2.3.15 | Fermeture Blindage | 1d? | 2018-02-13 | 2018-02-13 | 46SS | 23d |  |  |
| 64 | 3.2.3.16 | Remise en place exposition visite | 1d? | 2018-02-14 | 2018-02-14 | 47SS | 22d |  |  |

| ID | WBS | Task | Duration | Start | Finish | Predecessors | Baseline start | Baseline finish | Baseline duration | Total slack | Free slack | Constraint | Text1 | Text2 | Text6 | Text27 |
| --- | --- | --- | --- | --- | --- | --- | --- | --- | --- | --- | --- | --- | --- | --- | --- | --- |
| 65 | 3.3 | **STI** | 13d | 2018-01-08 | 2018-01-23 |  |  |  |  | 38d |  |  |  |  |  |  |
| 66 | 3.3.1 | Remplacement Scraper SHV1305 | 3d | 2018-01-08 | 2018-01-10 |  |  |  |  | 38d | 0d | start no earlier than 2018-01-08 |  |  |  |  |
| 67 | 3.3.2 | Bakeout | 10d | 2018-01-11 | 2018-01-23 | 66 |  |  |  | 38d |  |  |  |  |  |  |
| 68 | 3.4 | **VSC** | 55d? | 2017-12-19 | 2018-03-16 | 8 |  |  |  | 0d |  |  |  |  |  |  |
| 69 | 3.4.1 | **AD Ring** | 55d? | 2017-12-19 | 2018-03-16 |  |  |  |  | 0d |  |  |  |  |  |  |
| 70 | 3.4.1.1 | **WORK IN AD RING + EXPERIMENTAL LINES for TE-VSC** | 55d? | 2017-12-19 | 2018-03-16 |  | 1999-12-13 | 2000-03-01 | 58d | 0d |  |  | 122 days |  |  |  |
| 71 | 3.4.1.1.1 | Check all VPS;VPI;VPGs;VGP | 1d? | 2017-12-19 | 2017-12-19 |  |  |  |  | 54d |  | start no earlier than 2017-12-14 |  |  |  |  |
| 72 | 3.4.1.1.2 | Check all VGI | 1d? | 2017-12-19 | 2017-12-19 |  |  |  |  | 54d |  | start no earlier than 2017-12-04 |  |  |  |  |
| 73 | 3.4.1.1.3 | Test of Local VGI power supplies | 1d? | 2017-12-19 | 2017-12-19 |  |  |  |  | 54d |  | start no earlier than 2017-12-19 |  |  |  |  |
| 74 | 3.4.1.1.4 | Global survey VPI connectors | 1d | 2018-01-08 | 2018-01-08 |  |  |  |  | 50d |  | start no earlier than 2018-01-08 |  |  |  |  |
| 75 | 3.4.1.1.5 | Install bakeout on VPI feedthrough | 1d? | 2018-01-15 | 2018-01-15 |  |  |  |  | 44d |  | start no earlier than 2018-01-15 |  |  |  |  |
| 76 | 7.9 | **Line 6000** | 36d | 2017-12-19 | 2018-02-19 |  | 1999-12-03 | 2000-03-07 | 58d | 19d |  |  | 1 day |  |  |  |
| 77 | 3.4.1.1.6.1 | Vent the sector | 1d | 2017-12-19 | 2017-12-19 |  |  |  |  | 54d |  |  |  |  |  |  |
| 78 | 3.4.1.1.6.2 | Oil change of Primary pump line 6000 | 1d | 2018-01-08 | 2018-01-08 |  |  |  |  | 50d |  | start no earlier than 2018-01-08 |  |  |  |  |
| 79 | 3.4.1.1.6.3 | Pump down & leak detection | 1d | 2018-02-19 | 2018-02-19 |  |  |  |  | 19d |  | start no earlier than 2018-02-19 |  |  |  |  |
| 80 | 7.9 | **SECTOR1A** | 13d | 2017-12-19 | 2018-01-17 |  | 1999-12-03 | 2000-03-07 | 58d | 12d |  |  | 1 day |  |  |  |
| 81 | 3.4.1.1.7.1 | RGA scan Septum 53 | 1d | 2017-12-19 | 2017-12-19 |  |  |  |  | 53d | 0d | start no earlier than 2017-12-18 |  | YES | YES | AS |
| 82 | 3.4.1.1.7.2 | Vent the sector | 1d | 2017-12-20 | 2017-12-20 | 81 |  |  |  | 53d |  |  |  |  |  |  |
| 83 | 3.4.1.1.7.3 | Exchange of the Pirani/Penning tee position 47 | 1d | 2018-01-17 | 2018-01-17 |  |  |  |  | 42d |  | start no earlier than 2018-01-17 |  |  |  |  |
| 84 | 3.4.1.1.7.4 | Installation of the pumping stations | 1d | 2018-01-09 | 2018-01-09 |  |  |  |  | 47d | 0d | start no earlier than 2018-01-09 |  |  |  |  |
| 85 | 3.4.1.1.7.5 | Inspection of sublimators filament, exchange of the position 47 | 2d | 2018-01-10 | 2018-01-11 | 84 |  |  |  | 47d |  |  |  |  |  |  |
| 86 | 3.4.1.1.7.6 | Replacement of the VPI 50 & 54 | 2d | 2018-01-15 | 2018-01-16 |  |  |  |  | 43d |  | start no earlier than 2018-01-15 |  |  |  |  |
| 87 | 3.4.1.1.8 | **Magnets group Sector 1A - support for TE-MSC** | 32d | 2017-12-20 | 2018-02-14 |  |  |  |  | 12d |  |  |  |  |  |  |
| 88 | 3.4.1.1.8.1 | Disconnection of the BHS 52 vacuum chamber sector 1A side and injection vacuum chamber | 1d | 2017-12-20 | 2017-12-20 | 82SS |  |  |  | 21d | 0d |  |  |  |  |  |
| 89 | 3.4.1.1.8.2 | Cut the injection vacuum chamber inside BHS 52 | 1d | 2017-12-20 | 2017-12-20 | 82SS |  |  |  | 21d | 0d |  |  |  |  |  |
| 90 | 3.4.1.1.8.3 | Disconnection of the Quadrupoles QDN 55, QFN 56 | 2d | 2017-12-20 | 2017-12-21 | 82SS |  |  |  | 7d | 0d |  |  |  |  |  |
| 91 | 3.4.1.1.8.4 | Consolidation of VPI port QFW50 | 2d | 2018-01-22 | 2018-01-23 |  |  |  |  | 36d | 0d | start no earlier than 2018-01-22 |  |  |  |  |
| 92 | 3.4.1.1.8.5 | Pump down of the partial sector 47 to 52 & leak detection | 2d | 2018-01-24 | 2018-01-25 | 91 |  |  |  | 36d |  |  |  |  |  |  |
| 93 | 3.4.1.1.8.6 | Reinstallation of the Quadrupoles QDN55, QFN56 | 2d | 2018-02-06 | 2018-02-07 |  |  |  |  | 6d | 0d | start no earlier than 2018-02-06 |  |  |  |  |
| 94 | 3.4.1.1.8.7 | Pump down of the partial sector 53 to 56 & leak detection | 2d | 2018-02-08 | 2018-02-09 | 93 |  |  |  | 6d | 0d |  |  |  |  |  |
| 95 | 3.4.1.1.8.8 | Reweld injection vacuum chamber inside BHS52 + leak test | 1d | 2018-02-12 | 2018-02-12 | 94 |  |  |  | 6d | 0d |  |  |  |  |  |
| 96 | 3.4.1.1.8.9 | Reinstallation of the BHS 52 with both vacuum chambers | 2d | 2018-02-13 | 2018-02-14 | 95 |  |  |  | 6d | 0d |  |  |  |  |  |

| ID | WBS | Task | Duration | Start | Finish | Predecessors | Baseline start | Baseline finish | Baseline duration | Total slack | Free slack | Constraint | Text1 | Text2 |
| --- | --- | --- | --- | --- | --- | --- | --- | --- | --- | --- | --- | --- | --- | --- |
| 97 | 3.4.1.1.9 | **Septa group Sector 1A - support for TE-ABT** | 21d | 2018-02-16 | 2018-03-16 |  |  |  |  | 0d |  |  |  |  |
| 98 | 3.4.1.1.9.1 | Pump down of the complete sector & leak detection | 1d | 2018-02-16 | 2018-02-16 | 96 |  |  |  | 5d | 0d | start no earlier than 2018-02-16 |  |  |
| 99 | 3.4.1.1.9.2 | Preparation Bake out | 1d | 2018-02-26 | 2018-02-26 | 98, 128 |  |  |  | 0d |  |  |  |  |
| 100 | 3.4.1.1.9.3 | Bake out time | 14d | 2018-02-27 | 2018-03-16 | 99 |  |  |  | 0d |  |  |  |  |
| 101 | 3.4.1.1.9.4 | Bake out disconnection | 1d | 2018-03-16 | 2018-03-16 | 100FF |  |  |  | 0d |  |  |  |  |
| 102 | 3.4.1.1.10 | **SECTOR1B** | 1d? | 2017-12-19 | 2017-12-19 |  | 1999-12-02 | 2000-03-07 | 59d | 54d |  |  | 1 day |  |
| 103 | 3.4.1.1.10.1 | RGA scan Tank 04 | 1d? | 2017-12-19 | 2017-12-19 |  |  |  |  | 54d |  |  |  |  |
| 104 | 7.11 | **SECTOR2A** | 1d | 2018-01-29 | 2018-01-29 |  | 1999-12-13 | 2000-03-21 | 62d | 34d |  |  | 73 days |  |
| 105 | 3.4.1.1.11.1 | Inspection for Scrapper consolidation | 1d | 2018-01-29 | 2018-01-29 |  |  |  |  | 34d |  | start no earlier than 2018-01-29 |  |  |
| 106 | 7.12 | **SECTOR2B** | 9d? | 2018-01-22 | 2018-02-01 |  | 1999-12-03 | 2000-01-21 | 26d | 31d |  |  | 55 days |  |
| 107 | 3.4.1.1.12.1 | Consolidation of VPI port (only if BHN20 is out) | 1d? | 2018-02-01 | 2018-02-01 |  |  |  |  | 31d |  | start no earlier than 2018-02-01 |  |  |
| 108 | 3.4.1.1.12.2 | Warm up sector | 5d | 2018-01-22 | 2018-01-26 |  |  |  |  | 32d | 0d | start no earlier than 2018-01-22 |  |  |
| 109 | 3.4.1.1.12.3 | Service of the cryohead systems | 3d | 2018-01-29 | 2018-01-31 | 108 |  |  |  | 32d |  |  |  |  |
| 110 | 7.12 | **SECTOR3** | 1d? | 2018-02-01 | 2018-02-01 |  | 1999-12-03 | 2000-01-21 | 26d | 31d |  |  | 55 days |  |
| 111 | 3.4.1.1.13.1 | RGA scan 27 | 1d? | 2018-02-01 | 2018-02-01 |  |  |  |  | 31d |  | start no earlier than 2018-02-01 |  |  |
| 112 | 3.4.1.1.14 | **SECTOR4** | 17d? | 2018-01-12 | 2018-02-02 |  | 1999-12-14 | 2000-03-20 | 0d | 30d |  |  |  |  |
| 113 | 3.4.1.1.14.1 | Warm up sector | 5d | 2018-01-22 | 2018-01-26 |  |  |  |  | 30d | 0d | start no earlier than 2018-01-22 |  |  |
| 114 | 3.4.1.1.14.2 | Service of the cryohead systems | 3d | 2018-01-29 | 2018-01-31 | 113 |  |  |  | 30d | 0d |  |  |  |
| 115 | 3.4.1.1.14.3 | Cool down the sector | 2d | 2018-02-01 | 2018-02-02 | 114 |  |  |  | 30d |  |  |  | YES |
| 116 | 3.4.1.1.14.4 | Gas injection system 42 maintenance | 1d? | 2018-01-12 | 2018-01-12 |  |  |  |  | 46d |  | start no earlier than 2018-01-12 |  |  |
| 117 | 3.4.1.1.15 | **DE EXPERIMENTAL LINES** | 3d? | 2018-03-01 | 2018-03-05 |  | 2000-03-01 | 2000-03-06 | 0d | 9d |  |  |  |  |
| 118 | 3.4.1.1.15.1 | Vent with nitrogen sector DE1.RFQD | 1d? | 2018-03-01 | 2018-03-01 |  |  |  |  | 9d | 0d | start no earlier than 2018-03-01 |  |  |
| 119 | 3.4.1.1.15.2 | Replacement of the gauge DE1.RFQD.VGP01 | 1d | 2018-03-01 | 2018-03-01 | 118SS |  |  |  | 11d |  |  |  |  |
| 120 | 3.4.1.1.15.3 | Pump down and leak detection | 1d? | 2018-03-02 | 2018-03-02 | 118 |  |  |  | 9d | 0d |  |  |  |
| 121 | 3.4.1.1.15.4 | Service of primary pump fixed pumping station BASE experiment | 1d | 2018-03-05 | 2018-03-05 | 120 |  |  |  | 9d |  |  |  |  |

| ID | WBS | Task | Duration | Start | Finish | Predecessors | Total slack | Free slack | Constraint | Resources | Work |
| --- | --- | --- | --- | --- | --- | --- | --- | --- | --- | --- | --- |
| 122 | 3.5 | **BCCC** | 55d | 2017-12-19 | 2018-03-16 |  | 0d |  |  |  |  |
| 123 | 3.5.1 | Installation of new controlled flow valve and insulation vacuum valve | 5d | 2017-12-19 | 2018-01-08 |  | 20d | 0d |  |  |  |
| 124 | 3.5.2 | Warm-up and purge cryostat | 5d | 2018-01-09 | 2018-01-13 | 123 | 20d | 0d |  |  |  |
| 125 | 3.5.3 | Pump insulation vacuum | 20d | 2018-01-15 | 2018-02-09 | 124 | 20d |  |  |  |  |
| 126 | 3.5.4 | Cool-down and refill | 5d | 2018-03-12 | 2018-03-16 | 125, 100FF | 0d |  |  |  |  |
| 127 | 3.6 | **CV** | 44d? | 2017-12-19 | 2018-03-01 |  | 11d |  |  |  |  |
| 128 | 3.6.1 | Maintenance eau déminéralisée | 5d | 2018-02-19 | 2018-02-23 |  | 0d |  | start no earlier than 2018-02-19 |  |  |
| 129 | 3.6.2 | Maintenance eau dure | 4d | 2018-02-26 | 2018-03-01 | 128 | 11d |  | start no earlier than 2017-03-23 |  |  |
| 130 | 3.6.3 | Maintemace generale BTV | 1d? | 2017-12-19 | 2017-12-19 |  | 54d |  |  |  |  |
| 131 | 3.7 | **RF** | 51d? | 2017-12-19 | 2018-03-12 |  | 4d |  |  |  |  |
| 132 | 3.7.1 | **ADC10** | 41d? | 2018-01-15 | 2018-03-12 |  | 4d |  |  |  |  |
| 133 | 3.7.1.1 | Maintenance ADC10 | 5d | 2018-01-15 | 2018-01-19 |  | 40d |  | start no earlier than 2018-01-15 |  |  |
| 134 | 3.7.1.2 | Power Test | 1d? | 2018-03-12 | 2018-03-12 |  | 4d |  | start no earlier than 2018-03-12 |  |  |
| 135 | 3.7.2 | **ADC02** | 1d? | 2017-12-19 | 2017-12-19 |  | 54d |  |  |  |  |
| 136 | 3.7.2.1 | Maintenance ADC02 | 1d? | 2017-12-19 | 2017-12-19 |  | 54d |  | start no earlier than 2017-03-20 |  |  |
| 137 | 3.7.2.2 | Test RF tube TH116 | 1d? | 2017-12-19 | 2017-12-19 |  | 54d |  |  |  |  |
| 138 | 3.8 | **EL** | 2d | 2018-01-13 | 2018-01-15 |  | 44d |  |  |  |  |
| 139 | 3.8.1 | Test AUG | 2d | 2018-01-13 | 2018-01-15 |  | 44d |  | start no earlier than 2018-01-13 |  |  |
| 140 | 3.9 | **Kickers** | 3d? | 2017-12-19 | 2017-12-21 |  | 52d |  |  |  |  |
| 141 | 3.9.1 | Maintenance generale | 1d? | 2017-12-19 | 2017-12-19 |  | 54d |  |  |  |  |
| 142 | 3.9.2 | Test | 3d | 2017-12-19 | 2017-12-21 |  | 52d |  | start no earlier than 2017-03-20 |  |  |
| 143 | 3.10 | **BI** | 16d | 2017-12-19 | 2018-01-22 |  | 39d |  |  |  | 24h |
| 144 | 3.10.1 | E-Cooler: Controle circuit de refroidissement | 1d | 2017-12-19 | 2017-12-19 | 8 | 54d |  | start no earlier than 2016-12-19 | Jean | 8h |
| 145 | 3.10.2 | Maintenance cartouche de resine | 2d | 2017-12-19 | 2017-12-20 |  | 53d |  | start no earlier than 2017-02-06 | Jean | 16h |
| 146 | 3.10.3 | Maintenance generale des BTV | 5d | 2018-01-16 | 2018-01-22 |  | 39d |  | start no earlier than 2018-01-16 |  |  |

| ID | WBS | Task | Duration | Start | Finish | Predecessors | Total slack | Constraint |
| --- | --- | --- | --- | --- | --- | --- | --- | --- |
| 147 | 3.11 | **RP** | 4d | 2018-01-08 | 2018-01-11 |  | 47d |  |
| 148 | 3.11.1 | tests source PMIA604, PAXA604, PAXPT113 | 4d | 2018-01-08 | 2018-01-11 |  | 47d | start no earlier than 2018-01-03 |
| 149 | 3.12 | **ICS** | 1d? | 2018-02-28 | 2018-02-28 |  | 12d |  |
| 150 | 3.12.1 | Access point maintenance (machine closed 9:00-13:00) Acces VSC (8:00-9:00) | 1d? | 2018-02-28 | 2018-02-28 |  | 12d | start no earlier than 2018-02-28 |
| 151 | 4 | **Hardware tests** | 10d | 2018-03-19 | 2018-03-30 | 9 | 0d |  |
| 152 | 4.1 | Hardware test | 10d | 2018-03-19 | 2018-03-30 |  | 0d | start no earlier than 2018-03-05 |
| 153 | 4.2 | **Kickers** | 3d | 2018-03-19 | 2018-03-21 |  | 7d |  |
| 154 | 4.2.1 | Test without acces | 3d | 2018-03-19 | 2018-03-21 |  | 7d |  |
| 155 | 4.3 | **RF** | 5d | 2018-03-19 | 2018-03-23 |  | 5d |  |
| 156 | 4.3.1 | Test ADC10 | 5d | 2018-03-19 | 2018-03-23 |  | 5d |  |
| 157 | 5 | **YETS ELENA** | 20d? | 2017-12-11 | 2018-01-18 |  | 51d |  |
| 158 | 5.1 | **E-Cooler** | 10d | 2017-12-11 | 2017-12-22 |  | 51d |  |
| 159 | 5.1.1 | Montage + Installation E-Cooler | 10d | 2017-12-11 | 2017-12-22 |  | 61d | start no earlier than 2017-12-11 |
| 160 | 5.2 | **LNS10-20** | 1d? | 2017-12-18 | 2017-12-18 |  | 65d |  |
| 161 | 5.2.1 | Exchange of the sector valve | 1d? | 2017-12-18 | 2017-12-18 |  | 65d |  |
| 162 | 5.2.2 | Exchange of the DN200 VVR valve for pumping station 5 | 1d? | 2017-12-18 | 2017-12-18 |  | 65d |  |
| 163 | 5.2.3 | Installation of the cable for source interlock (ICM) | 1d? | 2017-12-18 | 2017-12-18 |  | 65d |  |
| 164 | 5.2.4 | Installation of water cooling interlock (ICM) | 1d? | 2017-12-18 | 2017-12-18 |  | 65d |  |
| 165 | 5.3 | **LNI-LNE** | 1d? | 2017-12-18 | 2017-12-18 |  | 65d |  |
| 166 | 5.3.1 | Installation of 4 SEM grids | 1d? | 2017-12-18 | 2017-12-18 |  | 65d |  |
| 167 | 5.4 | **LNR 30-40-50** | 15d? | 2017-12-18 | 2018-01-18 |  | 51d |  |
| 168 | 5.4.1 | Venting with Neon | 1d? | 2017-12-18 | 2017-12-18 |  | 65d |  |
| 169 | 5.4.2 | Installation of Electron Cooler | 10d | 2018-01-08 | 2018-01-18 | 159 | 51d |  |
| 170 | 5.5 | **LNE50** | 1d? | 2017-12-18 | 2017-12-18 |  | 65d |  |
| 171 | 5.5.1 | installation of 1 SEM grod | 1d? | 2017-12-18 | 2017-12-18 |  | 65d |  |
| 172 | 5.5.2 | Installation of the Pick Up Longitudinal type B | 1d? | 2017-12-18 | 2017-12-18 |  | 65d |  |

| ID | WBS | Task | Duration | Start | Finish | Total slack | Constraint |
| --- | --- | --- | --- | --- | --- | --- | --- |
| 173 | 6 | **YETS Gbar** | 10d | 2018-01-15 | 2018-01-26 | 45d |  |
| 174 | 6.1 | Installation LINAC | 10d | 2018-01-15 | 2018-01-26 | 45d | start no earlier than 2018-01-15 |
